# Planning and PD&E (EIS).mpp

Schedule from Primavera P6, 2016-08-01 to 2021-10-26, data date 2016-08-01.
Must finish by 2021-10-26

## Calendars

- Standard: Mon-Sun off.

## Schedule

| ID | WBS | Activity | Type | Duration | Start | Finish | Predecessors | Total float | Constraint |
| --- | --- | --- | --- | --- | --- | --- | --- | --- | --- |
|  | 1 | **PLANNING ACTIVITES** |  |  | 2016-08-01 | 2017-07-17 |  |  |  |
| 1 |  | PLANNING ACTIVITES | WBS summary | 251d | 2016-08-01 | 2017-07-17 |  | 0d |  |
| 2 |  | District SWAT Planning Meeting (May take place 6 months to 5 years before SWAT Kickoff Meeting) | milestone | 0d | 2016-08-01 | 2016-08-01 |  | 0d | start on or after 2016-08-01 |
| 3 |  | District SWAT Strategy Meeting (6 months after the SWAT Planning Meeting when the Tentative Work Program has been submi | milestone | 0d | 2017-02-01 | 2017-02-01 | 2 FS+16.38d | 0d |  |
|  | 1.3 | **ETDM PROGRAMMING SCREEN** |  |  | 2017-03-03 | 2017-07-17 |  |  |  |
| 4 |  | ETDM PROGRAMMING SCREEN | WBS summary | 97d | 2017-03-03 | 2017-07-17 |  | 0d |  |
| 9 |  | ETDM PROGRAMMING SCREEN START/ADVANCE NOTIFICATION |  | 32d | 2017-03-31 | 2017-05-15 | 6, 7, 8 | 0d |  |
| 10 |  | ETDM Programming Screen Responses |  | 44d | 2017-05-16 | 2017-07-14 | 9 | 0d |  |
| 11 |  | ETDM PROGRAMMING PRELIMINARY SUMMARY REPORT PUBLISHED |  | 1d | 2017-07-17 | 2017-07-17 | 10 | 0d |  |
|  | 1.3.1 | **ETDM Programming Screen Meeting** |  |  | 2017-03-03 | 2017-03-30 |  |  |  |
| 5 |  | ETDM Programming Screen Meeting | WBS summary | 20d | 2017-03-03 | 2017-03-30 |  | 0d |  |
| 6 |  | ETDM Programming Screen PED |  | 20d | 2017-03-03 | 2017-03-30 | 3 FS+2.5d | 0d |  |
| 7 |  | ETDM Programming Screen Purpose and Need |  | 20d | 2017-03-03 | 2017-03-30 | 3 FS+2.5d | 0d |  |
| 8 |  | Planning Consistency Completion |  | 5d | 2017-03-03 | 2017-03-09 | 3 FS+2.5d | 15d |  |
|  | 2 | **PRE-PD&E ACTIVITIES** |  |  | 2017-08-01 | 2018-09-14 |  |  |  |
| 12 |  | PRE-PD&E ACTIVITIES | WBS summary | 294d | 2017-08-01 | 2018-09-14 |  | 0d |  |
| 13 |  | SWAT Kickoff Meeting | milestone | 0d | 2017-08-01 | 2017-08-01 | 11 FS+1.25d | 0d |  |
| 14 |  | Assign PD&E Project Manager |  | 1d | 2017-08-02 | 2017-08-02 | 13 | 0d |  |
|  | 2.3 | **Traffic Analysis** |  |  | 2017-08-03 | 2018-01-04 |  |  |  |
| 15 |  | Traffic Analysis | WBS summary | 111d | 2017-08-03 | 2018-01-04 | 7 | 0d |  |
| 16 |  | Traffic Methodology Meeting |  | 1d | 2017-08-03 | 2017-08-03 | 7, 14, 13 | 0d |  |
| 17 |  | Traffic Methodology Memorandum |  | 5d | 2017-08-04 | 2017-08-10 | 16 | 0d |  |
| 18 |  | Traffic Data Collection |  | 20d | 2017-08-11 | 2017-09-07 | 17 | 0d |  |
| 19 |  | Crash Data and Analysis |  | 20d | 2017-08-11 | 2017-09-07 | 17 | 60d |  |
| 20 |  | Prepare Traffic Projections |  | 30d | 2017-09-08 | 2017-10-19 | 18 | 0d |  |
| 21 |  | Prepare Capacity Analysis |  | 30d | 2017-10-20 | 2017-11-30 | 20 | 0d |  |
| 22 |  | Draft Project Traffic Analysis Report |  | 10d | 2017-12-01 | 2017-12-14 | 21, 19 | 0d |  |
| 23 |  | FDOT Review - Draft Project Traffic Analysis Report |  | 10d | 2017-12-15 | 2017-12-28 | 22 | 0d |  |
| 24 |  | Final Project Traffic Analysis Report |  | 5d | 2017-12-29 | 2018-01-04 | 23 | 0d |  |

| ID | WBS | Activity | Type | Duration | Start | Finish | Predecessors | Total float | Free float | Constraint |
| --- | --- | --- | --- | --- | --- | --- | --- | --- | --- | --- |
|  | 2.4 | **INTERCHANGE ACCESS REQUEST** |  |  | 2017-08-03 | 2018-09-14 |  |  |  |  |
| 25 |  | INTERCHANGE ACCESS REQUEST | WBS summary | 292d | 2017-08-03 | 2018-09-14 |  | 72d |  |  |
| 26 |  | Initiate IJR/IMR/SIMR or IOAR |  | 1d | 2017-08-03 | 2017-08-03 | 9, 14 | 132d | 0d |  |
| 27 |  | Prepare MLOU |  | 5d | 2017-08-04 | 2017-08-10 | 26 | 132d | 0d |  |
| 28 |  | DIRC/SPO Review of MLOU |  | 10d | 2017-08-11 | 2017-08-24 | 27 | 132d | 0d |  |
| 29 |  | FHWA Review of MLOU |  | 20d | 2017-08-25 | 2017-09-21 | 28 | 132d | 60d |  |
| 30 |  | Develop Alternatives |  | 30d | 2017-12-15 | 2018-01-25 | 29, 22 | 72d | 0d |  |
| 31 |  | Perform Operational Analysis |  | 30d | 2018-01-26 | 2018-03-08 | 30 | 72d | 0d |  |
| 32 |  | Prepare Preliminary IMR/IJR |  | 45d | 2018-03-09 | 2018-05-10 | 31 | 72d | 0d |  |
| 33 |  | DIRC/SPO Reviw of Preliminary IJR/IMR |  | 10d | 2018-05-11 | 2018-05-24 | 32 | 72d | 0d |  |
| 34 |  | FHWA Review of Preliminary IJR/IMR |  | 20d | 2018-05-25 | 2018-06-21 | 33 | 72d | 0d |  |
| 35 |  | Prepare Final IJR/IMR |  | 30d | 2018-06-22 | 2018-08-02 | 34 | 72d | 0d |  |
| 36 |  | DIRC/SPO Review of Final IJR/IMR |  | 10d | 2018-08-03 | 2018-08-16 | 35 | 72d | 0d |  |
| 37 |  | FHWA Review of IJR/IMR |  | 20d | 2018-08-17 | 2018-09-13 | 36 | 72d | 0d |  |
| 38 |  | IJR/IMR Approval |  | 1d | 2018-09-14 | 2018-09-14 | 37 | 72d |  |  |
|  | 2.5 | **DEVELOP SCOPE AND SCHEDULE** |  |  | 2018-01-05 | 2018-02-02 |  |  |  |  |
| 39 |  | DEVELOP SCOPE AND SCHEDULE | WBS summary | 21d | 2018-01-05 | 2018-02-02 |  | 0d |  |  |
| 40 |  | Begin PD&E Scope and Schedule |  | 20d | 2018-01-05 | 2018-02-01 | 11, 24 | 0d |  |  |
| 41 |  | PD&E SCOPE AND SCHEDULE COMPLETION |  | 1d | 2018-02-02 | 2018-02-02 | 40 | 0d |  |  |
|  | 2.6 | **PROCUREMENT** |  |  | 2018-02-05 | 2018-07-24 |  |  |  |  |
| 42 |  | PROCUREMENT | WBS summary | 122d | 2018-02-05 | 2018-07-24 |  | 0d |  |  |
| 43 |  | PD&E Advertisement |  | 1d | 2018-02-05 | 2018-02-05 | 41 | 0d |  |  |
| 44 |  | Procurement |  | 120d | 2018-02-06 | 2018-07-23 | 41, 43 | 0d |  |  |
| 45 |  | Notice to Proceed | milestone | 0d | 2018-07-24 | 2018-07-24 | 44 | 850d |  | start on or after 2016-04-01 |

| ID | WBS | Activity | Type | Duration | Start | Finish | Predecessors | Total float | Free float |
| --- | --- | --- | --- | --- | --- | --- | --- | --- | --- |
|  | 3 | **PD&E STUDY** |  |  | 2016-08-01 | 2021-10-26 |  |  |  |
| 46 |  | PD&E STUDY | WBS summary | 1367d | 2016-08-01 | 2021-10-26 |  | 0d |  |
|  | 3.1 | **PROJECT MANAGEMENT** |  |  | 2018-07-24 | 2018-08-22 |  |  |  |
| 47 |  | PROJECT MANAGEMENT | WBS summary | 22d | 2018-07-24 | 2018-08-22 |  | 0d |  |
| 48 |  | Prepare Project Management Plan |  | 5d | 2018-07-24 | 2018-07-30 | 44 | 0d |  |
| 49 |  | Prepare QC Plan |  | 5d | 2018-07-24 | 2018-07-30 | 44 | 0d |  |
| 50 |  | Project Kickoff Meeting with FDOT |  | 1d | 2018-07-31 | 2018-07-31 | 48, 49 | 0d |  |
| 51 |  | Prepare Draft Notice of Intent |  | 5d | 2018-08-01 | 2018-08-07 | 50 | 395d | 0d |
| 52 |  | District Review of Notice of Intent |  | 5d | 2018-08-08 | 2018-08-14 | 51 | 395d | 0d |
| 53 |  | OEM Review of Notice of Intent |  | 5d | 2018-08-15 | 2018-08-21 | 52 | 395d | 0d |
| 54 |  | Publish Notice of Intent in Federal Register |  | 1d | 2018-08-22 | 2018-08-22 | 53 | 395d |  |
|  | 3.2 | **PUBLIC INVOLVEMENT** |  |  | 2016-08-01 | 2021-05-24 |  |  |  |
| 55 |  | PUBLIC INVOLVEMENT | WBS summary | 1256d | 2016-08-01 | 2021-05-24 |  | 0d |  |
| 56 |  | Prepare Public Involvement Plan |  | 20d | 2016-08-01 | 2016-08-26 |  | 644d | 547d |
| 57 |  | Public Involvement Data Collection |  | 45d | 2018-08-01 | 2018-10-02 | 50 | 97d | 0d |
| 58 |  | Scoping Meeting |  | 1d | 2018-10-03 | 2018-10-03 | 56, 57 | 97d | 0d |
|  | 3.2.4 | **Prepare for Public Kickoff Meeting** |  |  | 2018-10-03 | 2019-01-02 |  |  |  |
| 59 |  | Prepare for Public Kickoff Meeting | WBS summary | 66d | 2018-10-03 | 2019-01-02 |  | 93d |  |
| 60 |  | Site Review |  | 1d | 2018-10-03 | 2018-10-03 | 91 FS-7.5d, 56, 57 | 112d | 0d |
| 61 |  | Newsletter |  | 20d | 2018-10-04 | 2018-10-31 | 60 | 112d | 0d |
| 62 |  | Newspaper Ad |  | 20d | 2018-10-04 | 2018-10-31 | 60 | 112d | 0d |
| 63 |  | Elected/Appointed/Property Owner Letters |  | 20d | 2018-10-04 | 2018-10-31 | 60 | 112d | 0d |
| 64 |  | Presentation/Display Material Review |  | 15d | 2018-11-01 | 2018-11-21 | 63, 61, 62 | 112d | 19d |
| 65 |  | Public Kickoff Meeting | milestone | 0d | 2018-12-19 | 2018-12-19 | 91, 86, 87, 88, 89, 93, 94, 64 | 93d | 0d |
| 66 |  | Public Comment Period |  | 10d | 2018-12-20 | 2019-01-02 | 65 | 93d | 64d |

| ID | WBS | Activity | Type | Duration | Start | Finish | Predecessors | Total float | Free float |
| --- | --- | --- | --- | --- | --- | --- | --- | --- | --- |
|  | 3.2.5 | **Prepare for Public Information Meeting** |  |  | 2019-04-03 | 2019-07-17 |  |  |  |
| 67 |  | Prepare for Public Information Meeting | WBS summary | 76d | 2019-04-03 | 2019-07-17 |  | 0d |  |
| 68 |  | Site Review |  | 1d | 2019-04-03 | 2019-04-03 | 111 FS-7.5d, 66 | 29d | 0d |
| 69 |  | Newsletter |  | 20d | 2019-04-04 | 2019-05-01 | 68 | 29d | 0d |
| 70 |  | Newspaper Ad |  | 20d | 2019-04-04 | 2019-05-01 | 68 | 29d | 0d |
| 71 |  | Elected/Appointed/Property Owner Letters |  | 20d | 2019-04-04 | 2019-05-01 | 68 | 29d | 0d |
| 72 |  | Presentation/Display Material Review |  | 15d | 2019-05-02 | 2019-05-22 | 68, 69, 70, 71 | 29d |  |
| 73 |  | Public Information Meeting | milestone | 0d | 2019-07-03 | 2019-07-03 | 111 FS+0.62d, 72, 34 | 0d |  |
| 74 |  | Public Comment Period |  | 10d | 2019-07-04 | 2019-07-17 | 73 | 0d |  |
|  | 3.2.6 | **Prepare for Public Hearing** |  |  | 2021-02-01 | 2021-05-24 |  |  |  |
| 75 |  | Prepare for Public Hearing | WBS summary | 81d | 2021-02-01 | 2021-05-24 |  | 0d |  |
| 76 |  | Site Review |  | 20d | 2021-02-01 | 2021-02-26 | 158 | 0d |  |
| 77 |  | Newsletter |  | 20d | 2021-03-01 | 2021-03-26 | 76 | 0d |  |
| 78 |  | Newspaper Ad |  | 20d | 2021-03-01 | 2021-03-26 | 76 | 0d |  |
| 79 |  | Elected/Appointed/Property Owner Letters |  | 20d | 2021-03-01 | 2021-03-26 | 76 | 0d |  |
| 80 |  | Presentation/Display Material Review |  | 15d | 2021-03-29 | 2021-04-16 | 76, 77, 78, 79 | 0d |  |
| 81 |  | Notice of Public Availability |  | 15d | 2021-04-19 | 2021-05-07 | 80 | 0d |  |
| 82 |  | Public Hearing | milestone | 0d | 2021-05-10 | 2021-05-10 | 81, 80, 162 | 0d |  |
| 83 |  | Public Comment Period |  | 10d | 2021-05-11 | 2021-05-24 | 82 | 0d |  |
|  | 3.3 | **ENGINEERING ANALYSIS** |  |  | 2018-08-01 | 2020-02-26 |  |  |  |
| 84 |  | ENGINEERING ANALYSIS | WBS summary | 411d | 2018-08-01 | 2020-02-26 |  | 0d |  |
|  | 3.3.1 | **Data Collection** |  |  | 2018-08-01 | 2018-12-18 |  |  |  |
| 85 |  | Data Collection | WBS summary | 100d | 2018-08-01 | 2018-12-18 |  | 93d |  |
| 89 |  | Geotechnical Data Collection |  | 50d | 2018-08-01 | 2018-10-09 | 50 | 143d | 50d |
| 90 |  | Topographic Survey and ROW Mapping |  | 50d | 2018-08-01 | 2018-10-09 | 50 | 93d | 0d |
| 86 |  | Roadway Data Collection |  | 50d | 2018-10-04 | 2018-12-12 | 50, 58 | 97d | 4d |
| 87 |  | Drainage Data Collection |  | 50d | 2018-10-04 | 2018-12-12 | 50, 58 | 97d | 4d |
| 88 |  | Bridge Data Collection |  | 50d | 2018-10-04 | 2018-12-12 | 50, 58 | 97d | 4d |
| 91 |  | Prepare Base Map |  | 50d | 2018-10-10 | 2018-12-18 | 50, 90 | 93d | 0d |

| ID | WBS | Activity | Type | Duration | Start | Finish | Predecessors | Total float | Free float |
| --- | --- | --- | --- | --- | --- | --- | --- | --- | --- |
|  | 3.3.2 | **Traffic Analysis** |  |  | 2018-08-01 | 2018-12-25 |  |  |  |
| 92 |  | Traffic Analysis | WBS summary | 105d | 2018-08-01 | 2018-12-25 |  | 0d |  |
| 93 |  | Traffic Data Collection |  | 20d | 2018-08-01 | 2018-08-28 | 50 | 0d |  |
| 94 |  | Crash Data and Analysis |  | 20d | 2018-08-01 | 2018-08-28 | 50 | 173d | 80d |
| 95 |  | Prepare Traffic Projections |  | 30d | 2018-08-29 | 2018-10-09 | 93 | 0d |  |
| 96 |  | Prepare Capacity Analysis |  | 30d | 2018-10-10 | 2018-11-20 | 95 | 0d |  |
| 97 |  | Draft Project Traffic Analysis Report |  | 10d | 2018-11-21 | 2018-12-04 | 96 | 0d |  |
| 98 |  | FDOT Review - Draft Project Traffic Analysis Report |  | 10d | 2018-12-05 | 2018-12-18 | 97 | 0d |  |
| 99 |  | Final Project Traffic Analysis Report |  | 5d | 2018-12-19 | 2018-12-25 | 98 | 0d |  |
|  | 3.3.3 | **Alternative Analysis** |  |  | 2018-12-05 | 2020-02-26 |  |  |  |
| 100 |  | Alternative Analysis | WBS summary | 321d | 2018-12-05 | 2020-02-26 |  | 15d |  |
| 101 |  | Typical Sections Analysis |  | 40d | 2018-12-05 | 2019-01-29 | 97 | 55d |  |
| 102 |  | Complete Streets/Multi Modal Analysis |  | 40d | 2018-12-05 | 2019-01-29 | 97 | 55d |  |
| 103 |  | Concept Development |  | 40d | 2018-12-26 | 2019-02-19 | 96, 99, 38 | 0d |  |
| 104 |  | Access Management Analysis |  | 40d | 2018-12-26 | 2019-02-19 | 99 | 40d |  |
| 105 |  | Drainage Analysis |  | 40d | 2019-02-20 | 2019-04-16 | 103 | 0d |  |
| 106 |  | Utility Coordination & Analysis |  | 40d | 2019-02-20 | 2019-04-16 | 103 | 0d |  |
| 107 |  | Railroad Coordination |  | 40d | 2019-02-20 | 2019-04-16 | 103 | 0d |  |
| 108 |  | Evaluation Matrix (1st Draft) |  | 5d | 2019-04-17 | 2019-04-23 | 101, 102, 105, 106, 107, 104, 103 | 0d |  |
| 109 |  | Construction Cost Estimates (LRE) |  | 10d | 2019-04-24 | 2019-05-07 | 108 | 30d |  |
| 110 |  | Right-of-Way Analysis |  | 20d | 2019-04-24 | 2019-05-21 | 108 | 20d |  |
| 111 |  | Evaluation Matrix (2nd Draft) |  | 5d | 2019-06-19 | 2019-06-25 | 109, 110, 123, 124, 125, 126, 127, 128 | 0d |  |
| 112 |  | Refine Alternatives (based on public input) |  | 20d | 2019-07-18 | 2019-08-14 | 74 | 574d |  |
| 113 |  | Prepare 1st DRAFT Engineering Reports (Drainage, Utility, Roadway Plans, ITS, Lighting, Pavement, Geotech, PER) |  | 30d | 2019-07-18 | 2019-08-28 | 74, 24, 99 | 0d |  |
| 114 |  | FDOT Review - 1st DRAFT Engineering Reports |  | 20d | 2019-08-29 | 2019-09-25 | 113 | 0d |  |
| 115 |  | Update DRAFT Engineering Reports |  | 15d | 2019-09-26 | 2019-10-16 | 114 | 0d |  |
| 116 |  | VE Study |  | 5d | 2019-10-17 | 2019-10-23 | 115 | 0d |  |
| 117 |  | VE Issues Resolution |  | 10d | 2019-11-21 | 2019-12-04 | 116 FS+2.5d | 0d |  |
| 118 |  | Prepare Typical Section Package |  | 20d | 2019-12-05 | 2020-01-01 | 117 | 0d |  |
| 119 |  | Prepare Design Variations and Exceptions |  | 20d | 2019-12-05 | 2020-01-01 | 117 | 0d |  |
| 120 |  | Typical Section Selection |  | 20d | 2020-01-02 | 2020-01-29 | 118, 119 | 0d |  |
| 121 |  | FDOT Review - 2nd DRAFT Engineering Reports (Drainage, Utility, Roadway Plans, ITS, Lighting, Pavement, Geotech, PER) |  | 20d | 2020-01-30 | 2020-02-26 | 118, 120 | 0d |  |

| ID | WBS | Activity | Type | Duration | Start | Finish | Predecessors | Total float | Free float |
| --- | --- | --- | --- | --- | --- | --- | --- | --- | --- |
|  | 3.4 | **ENVIRONMENTAL ANALYSIS** |  |  | 2019-04-24 | 2020-01-02 |  |  |  |
| 122 |  | ENVIRONMENTAL ANALYSIS | WBS summary | 182d | 2019-04-24 | 2020-01-02 |  | 0d |  |
| 123 |  | Data Collection & Cultural Resources Assessment Survey |  | 40d | 2019-04-24 | 2019-06-18 | 108, 58 | 0d |  |
| 124 |  | Data Collection & Noise Analysis |  | 40d | 2019-04-24 | 2019-06-18 | 108, 58 | 0d |  |
| 125 |  | Data Collection & Contamination Screen Evaluation |  | 40d | 2019-04-24 | 2019-06-18 | 108, 58 | 0d |  |
| 126 |  | Wetland Delineation and Evaluation |  | 40d | 2019-04-24 | 2019-06-18 | 108, 58 | 0d |  |
| 127 |  | Data Collection & Wildlife Survey |  | 40d | 2019-04-24 | 2019-06-18 | 108, 58 | 0d |  |
| 128 |  | Essential Fish Habitat Evaluation |  | 40d | 2019-04-24 | 2019-06-18 | 108, 58 | 0d |  |
| 129 |  | Determination of Section 4(f) |  | 15d | 2019-04-24 | 2019-05-14 | 108 | 110d | 0d |
| 134 |  | Prepare Draft Section 4(f) Evaluation |  | 30d | 2019-05-15 | 2019-06-25 | 129 | 110d | 25d |
| 130 |  | Prepare 1st Draft Natural Resource Evaluation Report |  | 30d | 2019-06-19 | 2019-07-30 | 126, 127, 128 | 85d | 0d |
| 131 |  | Prepare 1st Draft Cultural Resources Assessment Survey |  | 30d | 2019-06-19 | 2019-07-30 | 123 | 85d | 0d |
| 132 |  | Prepare 1st Draft Contamination Screen Evaluation Report |  | 30d | 2019-06-19 | 2019-07-30 | 125 | 85d | 0d |
| 133 |  | Prepare 1st Draft Noise Study Report |  | 30d | 2019-06-19 | 2019-07-30 | 124 | 85d | 0d |
| 135 |  | FDOT Review 1st DRAFT Environmental Reports (NRE, CSER, CRAS, Noise, Section 4(f)) |  | 20d | 2019-07-31 | 2019-08-27 | 130, 131, 132, 133, 134 | 85d | 0d |
| 136 |  | Update Environmental Reports |  | 15d | 2019-08-28 | 2019-09-17 | 135 | 85d | 0d |
| 137 |  | Finalize Cultural Resources Assessment Survey |  | 10d | 2019-09-18 | 2019-10-01 | 136 | 85d | 46d |
| 138 |  | Finalize Natural Resource Evaluation Report |  | 10d | 2019-09-18 | 2019-10-01 | 136 | 95d | 46d |
| 139 |  | Submit CRAS to OEM |  | 20d | 2019-12-05 | 2020-01-01 | 136, 117, 137 | 39d | 0d |
| 141 |  | Submit NRE to USFWS |  | 1d | 2019-12-05 | 2019-12-05 | 117, 138 | 49d | 0d |
| 142 |  | Submit NRE to NMFS |  | 1d | 2019-12-05 | 2019-12-05 | 117, 138 | 49d | 0d |
| 145 |  | Prepare Conceptual Relocation Plan |  | 20d | 2019-12-05 | 2020-01-01 | 117 | 40d |  |
| 143 |  | Informal USFWS Consultation Complete |  | 10d | 2019-12-06 | 2019-12-19 | 141 | 49d |  |
| 144 |  | Informal NMFS Consultation Complete |  | 10d | 2019-12-06 | 2019-12-19 | 142 | 49d |  |
| 140 |  | SHPO Consultation Complete |  | 1d | 2020-01-02 | 2020-01-02 | 139 | 39d |  |

| ID | WBS | Activity | Type | Duration | Start | Finish | Predecessors | Planned start | Planned finish | Total float | Free float |
| --- | --- | --- | --- | --- | --- | --- | --- | --- | --- | --- | --- |
|  | 3.5 | **FINAL ENVIRONMENTAL IMPACT STATEMENT DOCUMENTS** |  |  | 2020-02-27 | 2021-10-26 |  |  |  |  |  |
| 146 |  | FINAL ENVIRONMENTAL IMPACT STATEMENT DOCUMENTS | WBS summary | 434d | 2020-02-27 | 2021-10-26 |  |  |  | 0d |  |
| 147 |  | Prepare 1st DRAFT Environmental Impact Statement |  | 50d | 2020-02-27 | 2020-05-06 | 117, 11, 140, 143, 144, 145, 8, 54, 121 |  |  | 0d |  |
| 148 |  | District Review DRAFT Environmental Impact Statement |  | 20d | 2020-05-07 | 2020-06-03 | 147 |  |  | 0d |  |
| 149 |  | Prepare 2nd DRAFT Environmental Impact Statement |  | 30d | 2020-06-04 | 2020-07-15 | 148 |  |  | 0d |  |
| 150 |  | OEM Review of 2nd DRAFT Environmental Impact Statement |  | 20d | 2020-07-16 | 2020-08-12 | 149 |  |  | 0d |  |
| 151 |  | Central Office Legal Sufficiency Review |  | 20d | 2020-07-16 | 2020-08-12 | 149 |  |  | 0d |  |
| 152 |  | Prepare 3rd DRAFT Environmental Impact Statement |  | 20d | 2020-08-13 | 2020-09-09 | 150, 151 |  |  | 0d |  |
| 153 |  | OEM Review of 3rd DRAFT Environmental Impact Statement |  | 20d | 2020-09-10 | 2020-10-07 | 152 |  |  | 0d |  |
| 154 |  | Prepare 4th DRAFT Environmental Impact Statement |  | 30d | 2020-10-08 | 2020-11-18 | 153 |  |  | 0d |  |
| 155 |  | Cooperating Agencies Review of 4th DRAFT Environmental Impact Statement |  | 20d | 2020-11-19 | 2020-12-16 | 154 |  |  | 0d |  |
| 156 |  | Prepare 5th DRAFT Environmental Impact Statement |  | 30d | 2020-12-17 | 2021-01-27 | 155 |  |  | 0d |  |
| 157 |  | Submit 5th DRAFT Environmental Impact Statement to OEM |  | 1d | 2021-01-28 | 2021-01-28 | 156 |  |  | 0d |  |
| 158 |  | DRAFT Environmental Impact Statement OEM Approval |  | 1d | 2021-01-29 | 2021-01-29 | 157 |  |  | 0d |  |
| 159 |  | Upload DRAFT Environmental Impact Statement to ETDM for Electronic Distribution |  | 1d | 2021-02-01 | 2021-02-01 | 158 |  |  | 191d |  |
| 160 |  | Distribute DRAFT Environmental Impact Statement (Hard Copies) |  | 1d | 2021-02-01 | 2021-02-01 | 158 |  |  | 191d |  |
| 161 |  | District Files DRAFT Environmental Impact Statement with EPA |  | 1d | 2021-02-01 | 2021-02-01 | 158 |  |  | 29d | 0d |
| 162 |  | EPA Publishes Notice of Availability in Federal Register |  | 40d | 2021-02-02 | 2021-03-29 | 161 |  |  | 29d |  |
| 163 |  | Finalize Engineering & Environmental Reports |  | 10d | 2021-05-25 | 2021-06-07 | 162, 83 |  |  | 0d |  |
| 164 |  | Finalize Section 4(f) Evaluation |  | 5d | 2021-05-25 | 2021-05-31 | 162, 83 |  |  | 5d |  |
| 165 |  | Finalize Noise Study Report |  | 5d | 2021-05-25 | 2021-05-31 | 162, 83 |  |  | 5d |  |
| 166 |  | Finalize Preliminary Engineering Report |  | 5d | 2021-05-25 | 2021-05-31 | 162, 83 |  |  | 5d |  |
| 167 |  | Prepare FINAL Environmental Impact Statement |  | 10d | 2021-06-08 | 2021-06-21 | 83, 163, 164, 165, 166 |  |  | 0d |  |
| 168 |  | FINAL Environmental Impact Statement to OEM |  | 1d | 2021-06-22 | 2021-06-22 | 167 |  |  | 0d |  |
| 169 |  | OEM Review of FINAL Environmental Impact Statement |  | 5d | 2021-06-23 | 2021-06-29 | 168 |  |  | 0d |  |
| 170 |  | Cooperating Agencies Review of FINAL Environmental Impact Statement |  | 5d | 2021-06-30 | 2021-07-06 | 169 |  |  | 0d |  |
| 171 |  | Prepare DRAFT Record of Decision |  | 5d | 2021-07-07 | 2021-07-13 | 169, 170 |  |  | 0d |  |
| 172 |  | OEM Review of DRAFT Record of Decision |  | 5d | 2021-07-14 | 2021-07-20 | 171, 170 |  |  | 0d |  |
| 173 |  | CO Legal Suffiency Review (FEIS and ROD) |  | 5d | 2021-07-21 | 2021-07-27 | 168, 172 |  |  | 0d |  |
| 174 |  | OEM Approves FINAL Environmental Impact Statement and Record of Decision |  | 1d | 2021-07-28 | 2021-07-28 | 173 |  |  | 0d |  |
| 175 |  | Upload FINAL Environmental Impact Statement to ETDM for Electronic Distribution |  | 1d | 2021-07-29 | 2021-07-29 | 174 |  |  | 0d |  |
| 176 |  | Distribute FINAL Environmental Impact Statement (Hard Copies) |  | 1d | 2021-07-29 | 2021-07-29 | 174 |  |  | 0d |  |
| 177 |  | District Place Notice of Availability in Local Newspaper(s) |  | 1d | 2021-07-29 | 2021-07-29 | 174 |  |  | 0d |  |
| 178 |  | District Files FINAL Environmental Impact Statement with EPA |  | 1d | 2021-07-29 | 2021-07-29 | 174 |  |  | 0d |  |
| 179 |  | OEM Signs Record of Decision and FINAL Environmental Impact Statement |  | 20d | 2021-10-08 | 2021-10-08 | 178, 175, 176, 177 | 2021-07-30 | 2021-08-26 | 0d |  |
| 180 |  | OEM Signs Record of Decision and FINAL Environmental Impact Statement |  | 1d | 2021-10-08 | 2021-10-08 | 179 FS+3.75d |  |  | 0d |  |
| 181 |  | Location Design Concept Acceptance | milestone | 0d | 2021-10-11 | 2021-10-11 | 180 |  |  | 0d |  |
| 182 |  | Publish Notification of Record of Decision and FINAL Environmental Impact Statement in Local Newspapers |  | 1d | 2021-10-12 | 2021-10-12 | 181 |  |  | 9d |  |
| 183 |  | Pass the Torch Meeting |  | 1d | 2021-10-26 | 2021-10-26 | 181 FS+1.25d, 182 |  |  | 0d |  |
