# Planning, PD&E (SEIR).mpp

Schedule from Primavera P6, 2016-08-01 to 2020-04-03, data date 2016-08-01.
Must finish by 2020-04-03

## Calendars

- Standard: Mon-Sun off.

## Schedule

| ID | WBS | Activity | Type | Duration | Start | Finish | Predecessors | Total float | Constraint |
| --- | --- | --- | --- | --- | --- | --- | --- | --- | --- |
|  | 1 | **PLANNING ACTIVITIES** |  |  | 2016-08-01 | 2017-07-17 |  |  |  |
| 1 |  | PLANNING ACTIVITIES | WBS summary | 251d | 2016-08-01 | 2017-07-17 |  | 0d |  |
| 2 |  | District SWAT Strategy Meeting (May take place 6 months to 5 years before SWAT Kickoff Meeting) | milestone | 0d | 2016-08-01 | 2016-08-01 |  | 0d | start on or after 2016-08-01 |
| 3 |  | District SWAT Strategy Meeting (6 months after the SWAT Planning Meeting when the Tentative Work Program has been submit |  | 2d | 2017-02-01 | 2017-02-02 | 2 FS+16.38d | 0d |  |
|  | 1.3 | **ETDM PROGRAMMING SCREEN** |  |  | 2017-03-03 | 2017-07-17 |  |  |  |
| 4 |  | ETDM PROGRAMMING SCREEN | WBS summary | 97d | 2017-03-03 | 2017-07-17 |  | 0d |  |
| 9 |  | ETDM PROGRAMMING SCREEN START/ADVANCE NOTIFICATION |  | 32d | 2017-03-31 | 2017-05-15 | 6, 7, 8 | 0d |  |
| 10 |  | ETDM Programming Screen Responses |  | 44d | 2017-05-16 | 2017-07-14 | 9 | 0d |  |
| 11 |  | ETDM PROGRAMMING PRELIMINARY SUMMARY REPORT PUBLISHED |  | 1d | 2017-07-17 | 2017-07-17 | 10 | 0d |  |
|  | 1.3.1 | **ETDM Programming Screen Meeting** |  |  | 2017-03-03 | 2017-03-30 |  |  |  |
| 5 |  | ETDM Programming Screen Meeting | WBS summary | 20d | 2017-03-03 | 2017-03-30 |  | 0d |  |
| 6 |  | ETDM Programming Screen PED |  | 20d | 2017-03-03 | 2017-03-30 | 3 FS+2.5d | 0d |  |
| 7 |  | ETDM Programming Screen Purpose and Need |  | 20d | 2017-03-03 | 2017-03-30 | 3 FS+2.5d | 0d |  |
| 8 |  | Planning Consistency Completion |  | 5d | 2017-03-03 | 2017-03-09 | 3 FS+2.5d | 801d |  |
|  | 2 | **PRE-PD&E ACTIVITIES** |  |  | 2017-08-01 | 2018-07-31 |  |  |  |
| 12 |  | PRE-PD&E ACTIVITIES | WBS summary | 261d | 2017-08-01 | 2018-07-31 |  | 0d |  |
| 13 |  | SWAT Kickoff Meeting | milestone | 0d | 2017-08-01 | 2017-08-01 | 11 FS+1.25d | 0d |  |
| 14 |  | Assign PD&E Project Manager |  | 1d | 2017-08-02 | 2017-08-02 | 13 | 0d |  |
|  | 2.3 | **TRAFFIC FORECAST ANALYSIS** |  |  | 2017-08-03 | 2018-01-11 |  |  |  |
| 15 |  | TRAFFIC FORECAST ANALYSIS | WBS summary | 116d | 2017-08-03 | 2018-01-11 | 7 | 0d |  |
| 16 |  | Traffic Methodology Meeting |  | 1d | 2017-08-03 | 2017-08-03 | 7, 14, 13 | 0d |  |
| 17 |  | Traffic Methodology Memorandum |  | 10d | 2017-08-04 | 2017-08-17 | 16 | 0d |  |
| 18 |  | Traffic Data Collection |  | 20d | 2017-08-18 | 2017-09-14 | 17 | 0d |  |
| 19 |  | Prepare Traffic Projections |  | 40d | 2017-09-15 | 2017-11-09 | 18 | 0d |  |
| 20 |  | Draft Project Traffic Analysis Report |  | 20d | 2017-11-10 | 2017-12-07 | 19 | 0d |  |
| 21 |  | FDOT Review - Draft Project Traffic Forecast Report |  | 15d | 2017-12-08 | 2017-12-28 | 20 | 0d |  |
| 22 |  | Final Project Traffic Forecast Report |  | 10d | 2017-12-29 | 2018-01-11 | 21 | 0d |  |

| ID | WBS | Activity | Type | Duration | Start | Finish | Predecessors | Total float | Free float | Constraint |
| --- | --- | --- | --- | --- | --- | --- | --- | --- | --- | --- |
|  | 2.4 | **INTERCHANGE ACCESS REQUEST** |  |  | 2017-08-03 | 2018-07-13 |  |  |  |  |
| 23 |  | INTERCHANGE ACCESS REQUEST | WBS summary | 247d | 2017-08-03 | 2018-07-13 |  | 94d |  |  |
| 24 |  | Initiate IJR/IMR/SIMR or IOAR |  | 1d | 2017-08-03 | 2017-08-03 | 9, 14 | 169d | 0d |  |
| 25 |  | Prepare MLOU |  | 5d | 2017-08-04 | 2017-08-10 | 24 | 169d | 0d |  |
| 26 |  | DIRC/SPO Review of MLOU |  | 10d | 2017-08-11 | 2017-08-24 | 25 | 169d | 75d |  |
| 27 |  | Develop Alternatives |  | 30d | 2017-12-08 | 2018-01-18 | 20, 26 | 94d | 0d |  |
| 28 |  | Perform Operational Analysis |  | 30d | 2018-01-19 | 2018-03-01 | 27 | 94d | 0d |  |
| 29 |  | Prepare Preliminary IMR/IJR |  | 45d | 2018-03-02 | 2018-05-03 | 28 | 94d | 0d |  |
| 30 |  | DIRC/SPO Reviw of Preliminary IJR/IMR |  | 10d | 2018-05-04 | 2018-05-17 | 29 | 94d | 0d |  |
| 31 |  | Prepare Final IJR/IMR |  | 30d | 2018-05-18 | 2018-06-28 | 30 | 94d | 0d |  |
| 32 |  | DIRC/SPO Review of Final IJR/IMR |  | 10d | 2018-06-29 | 2018-07-12 | 31 | 94d | 0d |  |
| 33 |  | IJR/IMR Approval |  | 1d | 2018-07-13 | 2018-07-13 | 32 | 94d |  |  |
|  | 2.5 | **DEVELOP SCOPE AND SCHEDULE** |  |  | 2018-01-12 | 2018-02-09 |  |  |  |  |
| 34 |  | DEVELOP SCOPE AND SCHEDULE | WBS summary | 21d | 2018-01-12 | 2018-02-09 |  | 0d |  |  |
| 35 |  | Begin PD&E Scope and Schedule |  | 20d | 2018-01-12 | 2018-02-08 | 11, 22 | 0d |  |  |
| 36 |  | PD&E SCOPE AND SCHEDULE COMPLETION |  | 1d | 2018-02-09 | 2018-02-09 | 35 | 0d |  |  |
|  | 2.6 | **PROCUREMENT** |  |  | 2018-02-12 | 2018-07-31 |  |  |  |  |
| 37 |  | PROCUREMENT | WBS summary | 122d | 2018-02-12 | 2018-07-31 |  | 0d |  |  |
| 38 |  | PD&E Advertisement |  | 1d | 2018-02-12 | 2018-02-12 | 36 | 0d |  |  |
| 39 |  | Procurement |  | 120d | 2018-02-13 | 2018-07-30 | 36, 38 | 0d |  |  |
| 40 |  | Notice to Proceed | milestone | 0d | 2018-07-31 | 2018-07-31 | 39 | 0d |  | start on or after 2016-04-01 |
|  | 3 | **PD&E STUDY** |  |  | 2018-08-01 | 2020-04-03 |  |  |  |  |
| 41 |  | PD&E STUDY | WBS summary | 438d | 2018-08-01 | 2020-04-03 |  | 0d |  |  |
|  | 3.1 | **PROJECT MANAGEMENT** |  |  | 2018-08-01 | 2018-08-09 |  |  |  |  |
| 42 |  | PROJECT MANAGEMENT | WBS summary | 7d | 2018-08-01 | 2018-08-09 |  | 0d |  |  |
| 43 |  | SEIR START |  | 1d | 2018-08-01 | 2018-08-01 | 40 | 0d |  |  |
| 44 |  | Prepare Project Management Plan |  | 5d | 2018-08-02 | 2018-08-08 | 43 | 0d |  |  |
| 45 |  | Prepare QC Plan |  | 5d | 2018-08-02 | 2018-08-08 | 43 | 0d |  |  |
| 46 |  | Project Kickoff Meeting with FDOT |  | 1d | 2018-08-09 | 2018-08-09 | 44, 45 | 0d |  |  |

| ID | WBS | Activity | Type | Duration | Start | Finish | Predecessors | Total float | Free float |
| --- | --- | --- | --- | --- | --- | --- | --- | --- | --- |
|  | 3.2 | **PUBLIC INVOLVEMENT** |  |  | 2018-08-02 | 2020-01-28 |  |  |  |
| 47 |  | PUBLIC INVOLVEMENT | WBS summary | 389d | 2018-08-02 | 2020-01-28 |  | 0d |  |
| 48 |  | Prepare Public Involvement Plan |  | 20d | 2018-08-02 | 2018-08-29 | 43 | 93d | 31d |
| 49 |  | Public Involvement Data Collection |  | 45d | 2018-08-10 | 2018-10-11 | 46 | 62d | 0d |
|  | 3.2.3 | **Prepare for Public Kickoff Meeting** |  |  | 2018-10-12 | 2018-12-17 |  |  |  |
| 50 |  | Prepare for Public Kickoff Meeting | WBS summary | 47d | 2018-10-12 | 2018-12-17 |  | 62d |  |
| 51 |  | Site Review |  | 1d | 2018-10-12 | 2018-10-12 | 82 FS-7.5d, 48, 49 | 62d | 0d |
| 52 |  | Newsletter |  | 20d | 2018-10-15 | 2018-11-09 | 51 | 62d | 0d |
| 53 |  | Newspaper Ad |  | 20d | 2018-10-15 | 2018-11-09 | 51 | 62d | 0d |
| 54 |  | Elected/Appointed/Property Owner Letters |  | 20d | 2018-10-15 | 2018-11-09 | 51 | 62d | 0d |
| 55 |  | Presentation/Display Material Review |  | 15d | 2018-11-12 | 2018-11-30 | 54, 52, 53 | 62d | 0d |
| 56 |  | Public Kickoff Meeting | milestone | 0d | 2018-12-03 | 2018-12-03 | 82, 77, 78, 79, 80, 84, 55 | 62d | 0d |
| 57 |  | Public Comment Period |  | 10d | 2018-12-04 | 2018-12-17 | 56 | 62d | 33d |
|  | 3.2.4 | **Prepare for Public Information Meeting** |  |  | 2019-02-01 | 2019-05-17 |  |  |  |
| 58 |  | Prepare for Public Information Meeting | WBS summary | 76d | 2019-02-01 | 2019-05-17 |  | 0d |  |
| 59 |  | Site Review |  | 1d | 2019-02-01 | 2019-02-01 | 100 FS-7.5d, 57 | 29d | 0d |
| 60 |  | Newsletter |  | 20d | 2019-02-04 | 2019-03-01 | 59 | 29d | 0d |
| 61 |  | Newspaper Ad |  | 20d | 2019-02-04 | 2019-03-01 | 59 | 29d | 0d |
| 62 |  | Elected/Appointed/Property Owner Letters |  | 20d | 2019-02-04 | 2019-03-01 | 59 | 29d | 0d |
| 63 |  | Presentation/Display Material Review |  | 15d | 2019-03-04 | 2019-03-22 | 59, 60, 61, 62 | 29d |  |
| 64 |  | Public Information Meeting | milestone | 0d | 2019-05-03 | 2019-05-03 | 100 FS+0.62d, 63 | 0d |  |
| 65 |  | Public Comment Period |  | 10d | 2019-05-06 | 2019-05-17 | 64 | 0d |  |
|  | 3.2.5 | **Prepare for Public Hearing** |  |  | 2019-09-10 | 2020-01-28 |  |  |  |
| 66 |  | Prepare for Public Hearing | WBS summary | 101d | 2019-09-10 | 2020-01-28 |  | 0d |  |
| 67 |  | Site Review |  | 20d | 2019-09-10 | 2019-10-07 | 65, 137 FS-10d | 20d | 0d |
| 68 |  | Newsletter |  | 20d | 2019-10-08 | 2019-11-04 | 67 | 20d | 0d |
| 69 |  | Newspaper Ad |  | 20d | 2019-10-08 | 2019-11-04 | 67 | 20d | 0d |
| 70 |  | Elected/Appointed/Property Owner Letters |  | 20d | 2019-10-08 | 2019-11-04 | 67 | 20d | 0d |
| 71 |  | Presentation/Display Material Review |  | 15d | 2019-11-05 | 2019-11-25 | 67, 68, 69, 70 | 20d |  |
| 72 |  | Notice of Public Availability |  | 15d | 2019-12-24 | 2020-01-13 | 71, 137 FS-0.62d, 109, 110, 33 | 0d |  |
| 73 |  | Public Hearing | milestone | 0d | 2020-01-14 | 2020-01-14 | 72, 71 | 0d |  |
| 74 |  | Public Comment Period |  | 10d | 2020-01-15 | 2020-01-28 | 73 | 0d |  |

| ID | WBS | Activity | Type | Duration | Start | Finish | Predecessors | Total float | Free float |
| --- | --- | --- | --- | --- | --- | --- | --- | --- | --- |
|  | 3.3 | **ENGINEERING ANALYSIS** |  |  | 2018-08-10 | 2019-11-29 |  |  |  |
| 75 |  | ENGINEERING ANALYSIS | WBS summary | 341d | 2018-08-10 | 2019-11-29 |  | 0d |  |
|  | 3.3.1 | **Data Collection** |  |  | 2018-08-10 | 2018-09-20 |  |  |  |
| 76 |  | Data Collection | WBS summary | 30d | 2018-08-10 | 2018-09-20 |  | 113d |  |
| 77 |  | Roadway Data Collection |  | 30d | 2018-08-10 | 2018-09-20 | 46 | 113d | 51d |
| 78 |  | Drainage Data Collection |  | 30d | 2018-08-10 | 2018-09-20 | 46 | 113d | 51d |
| 79 |  | Bridge Data Collection |  | 30d | 2018-08-10 | 2018-09-20 | 46 | 113d | 51d |
| 80 |  | Geotechnical Data Collection |  | 30d | 2018-08-10 | 2018-09-20 | 46 | 113d | 51d |
| 81 |  | Topographic Survey and ROW Mapping |  | 30d | 2018-08-10 | 2018-09-20 | 46 | 401d |  |
| 82 |  | Prepare Base Map |  | 30d | 2018-08-10 | 2018-09-20 | 46 | 113d | 51d |
|  | 3.3.2 | **Traffic Analysis** |  |  | 2018-08-10 | 2018-11-22 |  |  |  |
| 83 |  | Traffic Analysis | WBS summary | 75d | 2018-08-10 | 2018-11-22 |  | 0d |  |
| 84 |  | Crash Data and Analysis |  | 20d | 2018-08-10 | 2018-09-06 | 46 | 123d | 61d |
| 85 |  | Prepare Capacity Analysis |  | 30d | 2018-08-10 | 2018-09-20 | 46 | 0d |  |
| 86 |  | Draft Project Traffic Analysis Report |  | 20d | 2018-09-21 | 2018-10-18 | 85 | 0d |  |
| 87 |  | FDOT Review - Draft Project Traffic Analysis Report |  | 15d | 2018-10-19 | 2018-11-08 | 86 | 0d |  |
| 88 |  | Final Project Traffic Analysis Report |  | 10d | 2018-11-09 | 2018-11-22 | 87 | 0d |  |
|  | 3.3.3 | **Alternative Analysis** |  |  | 2018-10-19 | 2019-11-29 |  |  |  |
| 89 |  | Alternative Analysis | WBS summary | 291d | 2018-10-19 | 2019-11-29 |  | 25d |  |
| 90 |  | Typical Sections Analysis |  | 30d | 2018-10-19 | 2018-11-29 | 86 | 65d |  |
| 91 |  | Complete Streets/Multi Modal Analysis |  | 30d | 2018-10-19 | 2018-11-29 | 86 | 65d |  |
| 92 |  | Concept Development |  | 40d | 2018-11-23 | 2019-01-17 | 85, 88, 33 | 0d |  |
| 93 |  | Access Management Analysis |  | 40d | 2018-11-23 | 2019-01-17 | 88 | 30d |  |
| 94 |  | Drainage Analysis |  | 30d | 2019-01-18 | 2019-02-28 | 92 | 0d |  |
| 95 |  | Utility Coordination & Analysis |  | 30d | 2019-01-18 | 2019-02-28 | 92 | 0d |  |
| 96 |  | Railroad Coordination |  | 30d | 2019-01-18 | 2019-02-28 | 92 | 0d |  |
| 97 |  | Evaluation Matrix (1st Draft) |  | 5d | 2019-03-01 | 2019-03-07 | 90, 91, 94, 95, 96, 93, 92 | 0d |  |
| 98 |  | Construction Cost Estimates (LRE) |  | 10d | 2019-03-08 | 2019-03-21 | 97 | 20d |  |
| 99 |  | Right-of-Way Analysis |  | 20d | 2019-03-08 | 2019-04-04 | 97 | 10d |  |
| 100 |  | Evaluation Matrix (2nd Draft) |  | 5d | 2019-04-19 | 2019-04-25 | 98, 99, 112, 113, 114, 115, 116, 117 | 0d |  |
| 101 |  | Refine Alternatives (based on public input) |  | 20d | 2019-05-20 | 2019-06-14 | 65 | 210d |  |
| 102 |  | Prepare 1st DRAFT Engineering Reports (Drainage, Utility, Roadway Plans, ITS, Lighting, Pavement, Geotech, PER) |  | 30d | 2019-05-20 | 2019-06-28 | 65, 22, 88 | 0d |  |
| 103 |  | FDOT Review - 1st DRAFT Engineering Reports |  | 20d | 2019-07-01 | 2019-07-26 | 102 | 0d |  |
| 104 |  | Update DRAFT Engineering Reports |  | 15d | 2019-07-29 | 2019-08-16 | 103 | 0d |  |
| 105 |  | VE Study |  | 5d | 2019-08-19 | 2019-08-23 | 104 | 0d |  |
| 106 |  | VE Issues Resolution |  | 10d | 2019-09-23 | 2019-10-04 | 105 FS+2.5d | 0d |  |
| 107 |  | Prepare Typical Section Package |  | 20d | 2019-10-07 | 2019-11-01 | 106 | 16d | 0d |
| 108 |  | Prepare Design Variations and Exceptions |  | 20d | 2019-10-07 | 2019-11-01 | 106 | 16d | 0d |
| 109 |  | Typical Section Selection |  | 20d | 2019-11-04 | 2019-11-29 | 107, 108 | 16d |  |
| 110 |  | FDOT Review - 2nd DRAFT Engineering Reports (Drainage, Utility, Roadway Plans, ITS, Lighting, Pavement, Geotech, PER) |  | 20d | 2019-11-04 | 2019-11-29 | 107 | 16d |  |

| ID | WBS | Activity | Type | Duration | Start | Finish | Predecessors | Total float | Free float |
| --- | --- | --- | --- | --- | --- | --- | --- | --- | --- |
|  | 3.4 | **ENVIRONMENTAL ANALYSIS** |  |  | 2019-03-08 | 2019-11-04 |  |  |  |
| 111 |  | ENVIRONMENTAL ANALYSIS | WBS summary | 172d | 2019-03-08 | 2019-11-04 |  | 0d |  |
| 112 |  | Data Collection & Cultural Resources Assessment Survey |  | 30d | 2019-03-08 | 2019-04-18 | 97 | 0d |  |
| 113 |  | Data Collection & Noise Analysis |  | 30d | 2019-03-08 | 2019-04-18 | 97 | 0d |  |
| 114 |  | Data Collection & Contamination Screen Evaluation |  | 30d | 2019-03-08 | 2019-04-18 | 97 | 0d |  |
| 115 |  | Wetland Delineation and Evaluation |  | 30d | 2019-03-08 | 2019-04-18 | 97 | 0d |  |
| 116 |  | Data Collection & Wildlife Survey |  | 30d | 2019-03-08 | 2019-04-18 | 97 | 0d |  |
| 117 |  | Essential Fish Habitat Evaluation |  | 30d | 2019-03-08 | 2019-04-18 | 97 | 0d |  |
| 118 |  | Determination of Section 4(f) |  | 15d | 2019-03-08 | 2019-03-28 | 97 | 61d | 0d |
| 123 |  | Prepare Draft Section 4(f) Evaluation |  | 30d | 2019-03-29 | 2019-05-09 | 118 | 61d | 15d |
| 119 |  | Prepare 1st Draft Natural Resource Evaluation Report |  | 30d | 2019-04-19 | 2019-05-30 | 115, 116, 117 | 46d | 0d |
| 120 |  | Prepare 1st Draft Cultural Resources Assessment Survey |  | 30d | 2019-04-19 | 2019-05-30 | 112 | 46d | 0d |
| 121 |  | Prepare 1st Draft Contamination Screen Evaluation Report |  | 30d | 2019-04-19 | 2019-05-30 | 114 | 46d | 0d |
| 122 |  | Prepare 1st Draft Noise Study Report |  | 30d | 2019-04-19 | 2019-05-30 | 113 | 46d | 0d |
| 124 |  | FDOT Review 1st DRAFT Environmental Reports (NRE, CSER, CRAS, Noise, Section 4(f)) |  | 20d | 2019-05-31 | 2019-06-27 | 119, 120, 121, 122, 123 | 46d | 0d |
| 125 |  | Update Environmental Reports |  | 15d | 2019-06-28 | 2019-07-18 | 124 | 46d | 0d |
| 126 |  | Finalize Cultural Resources Assessment Survey |  | 10d | 2019-07-19 | 2019-08-01 | 125 | 46d |  |
| 127 |  | Finalize Natural Resource Evaluation Report |  | 10d | 2019-07-19 | 2019-08-01 | 125 | 56d | 46d |
| 128 |  | Submit CRAS to OEM |  | 20d | 2019-10-07 | 2019-11-01 | 125, 106, 126 | 0d |  |
| 130 |  | Submit NRE to USFWS |  | 1d | 2019-10-07 | 2019-10-07 | 106, 127 | 10d | 0d |
| 131 |  | Submit NRE to NMFS |  | 1d | 2019-10-07 | 2019-10-07 | 106, 127 | 10d | 0d |
| 134 |  | Prepare Conceptual Relocation Plan |  | 20d | 2019-10-07 | 2019-11-01 | 106 | 1d |  |
| 132 |  | Informal USFWS Consultation Complete |  | 10d | 2019-10-08 | 2019-10-21 | 130 | 10d |  |
| 133 |  | Informal NMFS Consultation Complete |  | 10d | 2019-10-08 | 2019-10-21 | 131 | 10d |  |
| 129 |  | SHPO Consultation Complete |  | 1d | 2019-11-04 | 2019-11-04 | 128 | 0d |  |

| ID | WBS | Activity | Type | Duration | Start | Finish | Predecessors | Planned start | Planned finish | Total float |
| --- | --- | --- | --- | --- | --- | --- | --- | --- | --- | --- |
|  | 3.5 | **FINAL SEIR DOCUMENTS** |  |  | 2019-11-05 | 2020-04-03 |  |  |  |  |
| 135 |  | FINAL SEIR DOCUMENTS | WBS summary | 109d | 2019-11-05 | 2020-04-03 |  |  |  | 0d |
| 136 |  | Prepare DRAFT SEIR |  | 20d | 2019-11-05 | 2019-12-02 | 106, 11, 129, 132, 133, 134 |  |  | 0d |
| 137 |  | FDOT Review DRAFT SEIR |  | 20d | 2019-12-03 | 2019-12-30 | 136 |  |  | 0d |
| 138 |  | Finalize Engineering & Environmental Reports |  | 10d | 2020-01-29 | 2020-02-11 | 74 |  |  | 5d |
| 139 |  | Finalize Section 4(f) Evaluation |  | 5d | 2020-01-29 | 2020-02-04 | 74 |  |  | 0d |
| 140 |  | Finalize Noise Study Report |  | 5d | 2020-01-29 | 2020-02-04 | 74 |  |  | 0d |
| 141 |  | Finalize Preliminary Engineering Report |  | 5d | 2020-01-29 | 2020-02-04 | 74 |  |  | 10d |
| 142 |  | Prepare FINAL SEIR |  | 10d | 2020-02-05 | 2020-02-18 | 74, 139, 140 |  |  | 0d |
| 143 |  | Submit FINAL SEIR to District OEM |  | 20d | 2020-02-19 | 2020-03-17 | 142, 138, 141 |  |  | 0d |
| 144 |  | District Secretary Approval of SEIR | milestone | 0d | 2020-03-19 | 2020-03-19 | 143 FS+0.25d | 2020-03-20 | 2020-03-20 | 0d |
| 145 |  | Pass the Torch Meeting |  | 1d | 2020-04-03 | 2020-04-03 | 144 FS+1.25d |  |  | 0d |
